# Pipe Repairs & Improvement

Schedule from Primavera P6, 2031-06-02 to 2031-07-07, data date 2031-06-16, costs in USD, A marks actual dates.

## Calendars

- 5x8 Standard & Holiday: Mon-Fri 08:00-16:00; Sat-Sun off. Exceptions (off unless hours are given): 2031-07-04.

## Resources

| Resource | Group | Rate |
| --- | --- | --- |
| Lump Sum Price | labor | 1 |

## Schedule

| ID | WBS | Activity | Type | Duration | Start | Finish | Predecessors | Complete | Remaining | Planned start | Planned finish | Total float | Resources | Cost | Actual cost | Subcontractor |
| --- | --- | --- | --- | --- | --- | --- | --- | --- | --- | --- | --- | --- | --- | --- | --- | --- |
| A1000 |  | Contract Award Date | milestone | 0d | 2031-06-02 A | 2031-06-02 A |  | 100% |  |  |  |  |  |  |  |  |
| A1010 |  | Start Project | milestone | 0d | 2031-06-04 A | 2031-06-04 A | A1000 SS+6d | 100% |  |  |  |  |  |  |  |  |
| A1020 |  | Project Management | level of effort | 18d | 2031-06-04 A | 2031-07-07 | A1010 SS | 19% | 14.5d | 2031-06-04 | 2031-06-27 | 0d | Lump Sum Price [4000 h] | 4,000 | 777.78 | WR-I |
| A1030 |  | Project Completion Date | milestone | 0d | 2031-07-07 | 2031-07-07 | A1140 FF, A1020 FF |  |  |  |  | 0d |  |  |  |  |
|  | 1 | **Demolition Piping** |  |  | 2031-06-05 | 2031-06-06 |  |  |  |  |  |  |  |  |  |  |
| A1040 |  | Drain Piping System |  | 1d | 2031-06-05 A | 2031-06-05 A | A1010 SS | 100% |  | 2031-06-04 | 2031-06-04 |  | Lump Sum Price [1000 h] | 1,000 | 800 | WR-I |
| A1050 |  | Remove Damaged Piping |  | 1d | 2031-06-06 A | 2031-06-06 A | A1040 | 100% |  | 2031-06-05 | 2031-06-05 |  | Lump Sum Price [1800 h] | 1,800 | 1,400 | TQE |
|  | 2 | **Installation Piping System** |  |  | 2031-06-09 | 2031-07-07 |  |  |  |  |  |  |  |  |  |  |
|  | 1 | **Piping** |  |  | 2031-06-09 | 2031-06-27 |  |  |  |  |  |  |  |  |  |  |
| A1060 |  | Install Piping & Couplings |  | 3d | 2031-06-09 A | 2031-06-17 | A1050 | 50% | 1.5d | 2031-06-06 | 2031-06-10 | 0d | Lump Sum Price [4000 h] | 4,000 | 1,800 | TQE |
| A1070 |  | Test Piping at Pressure |  | 1d | 2031-06-17 | 2031-06-18 | A1060 |  |  |  |  | 0d | Lump Sum Price [1000 h] | 1,000 |  | TQE |
| A1080 |  | Insulate Piping |  | 4d | 2031-06-23 | 2031-06-27 | A1070, A1120 FF |  |  |  |  | 0d | Lump Sum Price [5000 h] | 5,000 |  | MPI |
|  | 2 | **Thrustblock** |  |  | 2031-06-18 | 2031-06-27 |  |  |  |  |  |  |  |  |  |  |
| A1090 |  | Set Forms |  | 1d | 2031-06-18 | 2031-06-19 | A1070 |  |  |  |  | 0d | Lump Sum Price [1000 h] | 1,000 |  | TQE |
| A1100 |  | Lay Rebar |  | 1d | 2031-06-19 | 2031-06-20 | A1090 |  |  |  |  | 0d | Lump Sum Price [2000 h] | 2,000 |  | TQE |
| A1110 |  | Pour Concrete |  | 1d | 2031-06-20 | 2031-06-23 | A1100 |  |  |  |  | 0d | Lump Sum Price [1000 h] | 1,000 |  | TQE |
| A1120 |  | Strike Forms |  | 1d | 2031-06-26 | 2031-06-27 | A1110 FS+9d |  |  |  |  | 0d | Lump Sum Price [600 h] | 600 |  | TQE |
|  | 3 | **Quality Assuarance** |  |  | 2031-06-27 | 2031-07-07 |  |  |  |  |  |  |  |  |  |  |
| A1130 |  | Write Quality Assurance Report |  | 4d | 2031-06-27 | 2031-07-03 | A1080 |  |  |  |  | 0d | Lump Sum Price [1000 h] | 1,000 |  | WR-I |
| A1140 |  | Final Quality Assurance Inspection |  | 1d | 2031-07-03 | 2031-07-07 | A1130 |  |  |  |  | 0d | Lump Sum Price [2000 h] | 2,000 |  | WR-I |

## Activity codes

| Code | Value | Meaning |
| --- | --- | --- |
| Subcontractor | MPI | Mechanical Pipe Insulators |
| Subcontractor | TQE | Total Quality Engineering |
| Subcontractor | WR-I | Walter Reed In-house |
